# Establecer la oficina de proyectos automatizada

Schedule from MS Project, 2013-10-02 to 2013-12-31, costs in $, A marks actual dates.
Linda Lawlor Consulting

## Calendars

- Standard: Mon-Fri 08:00-12:00, 13:00-17:00; Sat-Sun off.

## Resources

| Resource | Group | Rate |
| --- | --- | --- |
| Firma contratante | External | 85 |
| Cliente | Internal | 70 |
| Consultor | External | 75 |

## Schedule

| ID | WBS | Task | Type | Duration | Start | Finish | Predecessors | Complete | Remaining | Baseline start | Baseline finish | Baseline duration | Total slack | Constraint | Resources | Work | Actual work | Cost | Baseline cost | Actual cost | Text27 | Text29 |
| --- | --- | --- | --- | --- | --- | --- | --- | --- | --- | --- | --- | --- | --- | --- | --- | --- | --- | --- | --- | --- | --- | --- |
| 1 | 1 | **Iniciación** |  | 0.5d | 2013-10-02 A | 2013-10-02 A |  | 100% |  | 2013-10-02 | 2013-10-02 | 0.5d |  |  |  | 24h | 24h | 1,780 | 1,403.85 | 1,780 | Linda Lawlor | AV |
| 2 | 1.1 | Reunión y discusión sobre los requisitos de los clientes |  | 4h | 2013-10-02 A | 2013-10-02 A |  | 100% |  | 2013-10-02 | 2013-10-02 | 4h |  |  | Firma contratante; Cliente [300%]; Consultor | 20h | 20h | 1,480 | 1,028.85 | 1,480 | Linda Lawlor | AV |
| 3 | 1.2 | Resumen de requisitos, calendario y costos |  | 4h | 2013-10-02 A | 2013-10-02 A | 2 | 100% |  | 2013-10-02 | 2013-10-02 | 4h |  |  | Consultor | 4h | 4h | 300 | 375 | 300 | Linda Lawlor | AV |
| 4 | 1.3 | Contrato negociado | milestone | 0d | 2013-10-02 A | 2013-10-02 A | 3 | 100% |  | 2013-10-02 | 2013-10-02 | 0d |  |  |  |  |  |  |  |  | Linda Lawlor | AV |
| 5 | 2 | **Análisis de necesidades** |  | 1.12d | 2013-10-03 A | 2013-10-04 A |  | 100% |  | 2013-10-03 | 2013-10-04 | 1.12d |  |  |  | 12h | 12h | 885 | 944.71 | 885 | Linda Lawlor | AV |
| 6 | 2.1 | Detallar requisitos y recomendaciones |  | 1d | 2013-10-03 A | 2013-10-03 A | 4 | 100% |  | 2013-10-03 | 2013-10-03 | 1d |  |  | Consultor | 8h | 8h | 600 | 750 | 600 | Linda Lawlor | AV |
| 7 | 2.2 | Presentar al cliente |  | 1h | 2013-10-04 A | 2013-10-04 A | 6 | 100% |  | 2013-10-04 | 2013-10-04 | 1h |  |  | Cliente [300%]; Consultor | 4h | 4h | 285 | 194.71 | 285 | Linda Lawlor | AV |
| 8 | 2.3 | Aceptación del cliente | milestone | 0d | 2013-10-04 A | 2013-10-04 A | 7 | 100% |  | 2013-10-04 | 2013-10-04 | 0d |  |  | Firma contratante; Cliente; Consultor |  |  |  |  |  | Linda Lawlor | AV |
| 9 | 3 | **Control del marco de trabajo** |  | 2d | 2013-10-11 A | 2013-10-14 A |  | 100% |  | 2013-10-11 | 2013-10-14 | 2d |  |  |  | 55h | 55h | 4,030 | 2,954.33 | 4,030 | Linda Lawlor | AV |
| 10 | 3.1 | Facilitar las normas de sesión |  | 7h | 2013-10-11 A | 2013-10-11 A | 8 | 100% |  | 2013-10-11 | 2013-10-11 | 7h |  | must start on 2000-10-11 | Firma contratante; Cliente [300%]; Consultor | 35h | 35h | 2,590 | 1,800.48 | 2,590 | Linda Lawlor | AV |
| 11 | 3.2 | Elaborar y presentar el documento de control del marco de trabajo |  | 1d | 2013-10-12 A | 2013-10-14 A | 10 | 100% |  | 2013-10-12 | 2013-10-14 | 1d |  |  | Consultor | 8h | 8h | 600 | 750 | 600 | Linda Lawlor | AV |
| 12 | 3.3 | Revisión y retroalimentación del cliente |  | 0.5d | 2013-10-13 A | 2013-10-14 A | 11 | 100% |  | 2013-10-13 | 2013-10-14 | 0.5d |  |  | Cliente [300%] | 12h | 12h | 840 | 403.85 | 840 | Linda Lawlor | AV |
| 13 | 3.4 | Aprobación del cliente | milestone | 0d | 2013-10-13 A | 2013-10-13 A | 12FS+0.5d | 100% |  | 2013-10-13 | 2013-10-13 | 0d |  |  |  |  |  |  |  |  | Linda Lawlor | AV |
| 14 | 4 | **Entrenar - fase I - personal de ejecución** |  | 2d | 2013-10-16 A | 2013-10-18 A |  | 100% |  | 2013-10-16 | 2013-10-18 | 2d |  |  |  | 58h | 58h | 4,275 | 2,883.17 | 4,275 | Linda Lawlor | AV |
| 15 | 4.1 | Capacitar a los entrenadores |  | 2d | 2013-10-16 A | 2013-10-17 A | 13 | 100% |  | 2013-10-16 | 2013-10-17 | 2d |  | must start on 2000-10-16 | Consultor [75%]; Cliente [275%] | 56h | 56h | 4,130 | 2,755.77 | 4,130 | Linda Lawlor | AV |
| 16 | 4.2 | Actualizar el material didáctico de entrenamiento |  | 0.5d | 2013-10-17 A | 2013-10-17 A | 15FF | 100% |  | 2013-10-17 | 2013-10-17 | 0.5d |  |  | Cliente [25%]; Consultor [25%] | 2h | 2h | 145 | 127.4 | 145 | Linda Lawlor | AV |
| 17 | 4.3 | Certificar a los entrenadores | milestone | 0d | 2013-10-18 A | 2013-10-18 A | 16 | 100% |  | 2013-10-18 | 2013-10-18 | 0d |  |  |  |  |  |  |  |  | Linda Lawlor | AV |
| 18 | 5 | **Proyecto piloto** |  | 22d | 2013-10-23 A | 2013-11-22 |  | 23% | 16.92d | 2013-10-23 | 2013-11-22 | 22d | 27.5d |  |  | 104h | 24h | 7,760 | 9,269.23 | 1,760 | Linda Lawlor | AV |
| 19 | 5.1 | Configurar la unidad compartida |  | 1d | 2013-10-23 A | 2013-10-23 A | 17 | 100% |  | 2013-10-23 | 2013-10-23 | 1d |  |  | Cliente | 8h | 8h | 560 | 269.23 | 560 | Linda Lawlor | AV |
| 20 | 5.2 | Desarrollar plantillas |  | 1d | 2013-10-24 A | 2013-10-24 A | 19 | 100% |  | 2013-10-24 | 2013-10-24 | 1d |  |  | Consultor | 8h | 8h | 600 | 750 | 600 | Linda Lawlor | AV |
| 21 | 5.3 | Crear un fondo de recursos |  | 1d | 2013-10-25 A | 2013-10-25 A | 20 | 100% |  | 2013-10-25 | 2013-10-25 | 1d |  |  | Consultor | 8h | 8h | 600 | 750 | 600 | Linda Lawlor | AV |
| 22 | 5.4 | Desarrollar y vincular los proyectos al fondo de recursos |  | 1w | 2013-10-28 | 2013-11-01 | 21 |  |  | 2013-10-26 | 2013-11-01 | 1w | 41.5d |  | Consultor | 40h |  | 3,000 | 3,750 |  | Linda Lawlor | AV |
| 23 | 5.5 | Examinar la configuración |  | 1w | 2013-11-04 | 2013-11-08 | 21 |  |  | 2013-11-02 | 2013-11-08 | 1w | 36.5d |  | Consultor | 40h |  | 3,000 | 3,750 |  | Linda Lawlor | AV |
| 24 | 5.6 | Aprobación del proyecto piloto | milestone | 0d | 2013-11-22 A | 2013-11-22 A | 23 | 100% |  | 2013-11-22 | 2013-11-22 | 0d |  |  |  |  |  |  |  |  | Linda Lawlor | AV |

| ID | WBS | Task | Type | Duration | Start | Finish | Predecessors | Complete | Remaining | Baseline start | Baseline finish | Baseline duration | Total slack | Constraint | Resources | Work | Actual work | Cost | Baseline cost | Actual cost | Text27 | Text29 |
| --- | --- | --- | --- | --- | --- | --- | --- | --- | --- | --- | --- | --- | --- | --- | --- | --- | --- | --- | --- | --- | --- | --- |
| 25 | 6 | **Entrenamiento - fase II - a nivel corporativo** |  | 16d | 2013-11-06 A | 2013-11-27 |  | 99% | 0d | 2013-11-06 | 2013-11-27 | 16d | 0d |  |  | 360h | 360h | 28,800 | 20,330.76 | 28,800 | Linda Lawlor | AV |
| 26 | 6.1 | Nivel actual I |  | 1w | 2013-11-06 A | 2013-11-12 A | 24 | 100% |  | 2013-11-06 | 2013-11-12 | 1w |  | must start on 2000-11-06 | Cliente [300%] | 120h | 120h | 9,600 | 6,776.92 | 9,600 | Linda Lawlor | AV |
| 27 | 6.2 | Nivel actual II |  | 1w | 2013-11-14 A | 2013-11-20 A | 26 | 100% |  | 2013-11-14 | 2013-11-20 | 1w |  |  | Cliente [300%] | 120h | 120h | 9,600 | 6,776.92 | 9,600 | Linda Lawlor | AV |
| 28 | 6.3 | Nivel actuall III |  | 1w | 2013-11-21 A | 2013-11-27 A | 27 | 100% |  | 2013-11-21 | 2013-11-27 | 1w |  |  | Cliente [300%] | 120h | 120h | 9,600 | 6,776.92 | 9,600 | Linda Lawlor | AV |
| 29 | 6.4 | Entenamiento completado | milestone | 0d | 2013-11-27 | 2013-11-27 | 28 |  |  | 2013-11-27 | 2013-11-27 | 0d | 0d |  |  |  |  |  |  |  | Linda Lawlor | AV |
| 30 | 7 | **Despliegue corporativo** |  | 16.5d | 2013-12-05 | 2013-12-27 |  |  |  | 2013-12-05 | 2013-12-12 | 6d | 0d |  |  | 84h |  | 6,240 | 4,048.08 |  | Linda Lawlor | AV |
| 31 | 7.1 | **Proyectos individuales** |  | 16.5d | 2013-12-05 | 2013-12-27 |  |  |  | 2013-12-05 | 2013-12-12 | 6d | 0d |  |  | 84h |  | 6,240 | 4,048.08 |  | Linda Lawlor | AV |
| 32 | 7.1.1 | Asesorar la optimización y el desarrollo de proyectos |  | 3w | 2013-12-05 | 2013-12-25 | 29FS+1w |  |  | 2013-12-05 | 2013-12-11 | 1w | 0d |  | Consultor [50%] | 60h |  | 4,500 | 2,836.54 |  | Linda Lawlor | AV |
| 33 | 7.1.2 | Añadir proyectos a la unidad compartida |  | 0.75d | 2013-12-26 | 2013-12-26 | 32 |  |  | 2013-12-12 | 2013-12-12 | 0.5d | 0d |  | Cliente; Consultor | 12h |  | 870 | 605.77 |  | Linda Lawlor | AV |
| 34 | 7.1.3 | Vincular proyectos al fondo de recursos |  | 0.75d | 2013-12-26 | 2013-12-27 | 33 |  |  | 2013-12-12 | 2013-12-12 | 0.5d | 0d |  | Cliente; Consultor | 12h |  | 870 | 605.77 |  | Linda Lawlor | AV |
| 35 | 7.1.4 | Proyectos en línea | milestone | 0d | 2013-12-27 | 2013-12-27 | 34 |  |  | 2013-12-12 | 2013-12-12 | 0d | 2d |  |  |  |  |  |  |  | Linda Lawlor | AV |
| 36 | 8 | Operaciones automáticas - Oficina de proyectos | milestone | 0d | 2013-12-27 | 2013-12-27 | 34 |  |  | 2013-12-12 | 2013-12-12 | 0d | 0d |  |  |  |  |  |  |  | Linda Lawlor | AV |
| 37 | 9 | **Cierre del proyecto** |  | 2d | 2013-12-27 | 2013-12-31 | 36 |  |  | 2013-12-13 | 2013-12-20 | 5d | 0d |  |  | 16h |  | 1,200 | 1,500 |  | Linda Lawlor | AV |
| 38 | 9.1 | Lecciones aprendidas |  | 1d | 2013-12-27 | 2013-12-30 |  |  |  | 2013-12-13 | 2013-12-13 | 1d | 0d |  | Consultor | 8h |  | 600 | 750 |  | Linda Lawlor | AV |
| 39 | 9.2 | Reporte final |  | 1d | 2013-12-30 | 2013-12-31 | 38 |  |  | 2013-12-16 | 2013-12-16 | 1d | 0d |  | Consultor | 8h |  | 600 | 750 |  | Linda Lawlor | AV |
| 40 | 9.3 | Cierre de sesión del cliente | milestone | 0d | 2013-12-31 | 2013-12-31 | 39 |  |  | 2013-12-20 | 2013-12-20 | 0d | 0d | start no earlier than 2013-12-20 | Cliente |  |  |  |  |  | Linda Lawlor | AV |
